# holgraphy at ATF

Schedule from MS Project, 2005-11-01 to 2007-02-08, A marks actual dates.
ALMA

## Calendars

- Standard: Mon-Fri 08:00-12:00, 13:00-17:00; Sat-Sun off. Exceptions (off unless hours are given): 2006-09-04, 2006-10-09, 2006-11-23 to 2006-11-24.

## Resources

| Resource |
| --- |
| Debra S |
| Jeff M |
| Robert Lucas |

## Schedule

| ID | WBS | Task | Type | Duration | Start | Finish | Predecessors | Complete | Remaining | Total slack | Free slack | Constraint | Deadline | Text1 |
| --- | --- | --- | --- | --- | --- | --- | --- | --- | --- | --- | --- | --- | --- | --- |
| 1 | 1 | **Holography System** |  | 329d | 2005-11-01 A | 2007-02-08 |  | 79% | 68.77d | 0d |  |  |  |  |
| 2 | 1.1 | Develop transmitter electronics |  | 30w | 2005-11-01 A | 2006-05-29 A |  | 100% |  |  |  | start no earlier than 2005-11-01 |  | Antonio |
| 3 | 1.2 | Repackage holography receiver |  | 32w | 2005-11-01 A | 2006-06-12 A |  | 100% |  |  |  | start no earlier than 2005-11-01 |  | Antonio |
| 4 | 1.3 | Develop ancillary electronics (cabling, power supply, ABM, TE and 25MHz, etc.) |  | 30w | 2005-11-01 A | 2006-05-29 A |  | 100% |  |  |  | start no earlier than 2005-11-01 |  | Antonio |
| 5 | 1.4 | Develop control software |  | 10w | 2006-03-13 A | 2006-05-19 A |  | 100% |  |  |  | start no earlier than 2006-03-12 |  | Brian |
| 6 | 1.5 | Modify reduction software for data format |  | 10d | 2006-03-13 | 2006-03-24 |  |  |  | 199d |  | start no earlier than 2006-03-12 |  | Robert |
| 7 | 1.6 | Ship Tx cables and spare minirack to AOC |  | 5d | 2006-08-07 A | 2006-08-11 A |  | 100% |  |  |  | start no earlier than 2006-08-07 |  |  |
| 9 | 1.7 | **NTC: Rx and Tx** |  | 57d | 2006-06-19 A | 2006-09-06 |  | 83% | 9.5d | 2d |  |  |  |  |
| 10 | 1.7.1 | Integrate/test tx, rx at CV |  | 40d | 2006-06-19 A | 2006-08-11 A | 2, 3, 4, 5 | 100% |  |  |  | finish no earlier than 2006-08-11 |  | Antonio |
| 11 | 1.7.2 | System test at NTC |  | 4d | 2006-08-25 | 2006-08-30 | 10 |  |  | -21d | 0d | finish no earlier than 2006-08-30 |  |  |
| 12 | 1.7.3 | Pack |  | 1d | 2006-08-31 | 2006-08-31 | 11 |  |  | -21d | 0d |  |  | Antonio |
| 13 | 1.7.4 | Ship to AOC |  | 3d | 2006-09-01 | 2006-09-06 | 12 |  |  | -21d | 0d |  |  | Antonio |
| 14 | 1.7.5 | Receive Tx and Rx at AOC | milestone | 0d | 2006-09-06 | 2006-09-06 | 13 |  |  | 2d | 0d |  |  |  |
| 16 | 1.8 | **AOC and ATF preparation** |  | 28d | 2006-08-14 A | 2006-09-21 |  | 14% | 24.22d | 97d |  |  |  |  |
| 17 | 1.8.1 | Inspect Tower |  | 1d | 2006-08-14 | 2006-08-14 |  |  |  | 97d | 4d | start no earlier than 2006-08-14 |  |  |
| 18 | 1.8.2 | Install Tx cables |  | 7d | 2006-08-28 | 2006-09-06 | 17, 7 |  |  | 105d | 0d | start no earlier than 2006-08-28 |  |  |
| 19 | 1.8.3 | Install Tx at ATF and verify control |  | 3d | 2006-09-07 | 2006-09-11 | 14, 18 |  |  | 104d |  |  |  | Dick, Antonio |
| 20 | 1.8.4 | Prepare RF cables |  | 5d | 2006-08-14 A | 2006-08-18 A |  | 100% |  |  |  | finish no earlier than 2006-08-18 |  |  |
| 21 | 1.8.5 | Control software checkout at AOC |  | 5d | 2006-09-11 | 2006-09-15 | 14 |  |  | 0d |  | start no earlier than 2006-09-11 |  |  |
| 22 | 1.8.6 | Install RF and FO cables on tower |  | 1d | 2006-09-18 | 2006-09-18 | 21, 20 |  |  | 0d |  |  |  |  |
| 23 | 1.8.7 | Upgrade software at ATF |  | 3d | 2006-09-19 | 2006-09-21 | 22 |  |  | 0d |  |  |  |  |
| 24 | 1.8.8 | Prepare for mounting minirack in both antennas |  | 5d | 2006-08-28 | 2006-09-01 |  |  |  | -22d | 0d | start no earlier than 2006-08-28 |  |  |
| 25 | 1.8.9 | Antenna VA / AEC decision | milestone | 0d | 2006-09-11 | 2006-09-11 | 13SS |  |  | -26d | 0d | start no earlier than 2006-09-11 | 2006-09-11 |  |
| 26 | 1.8.10 | prepare antenna for electronics |  | 5d | 2006-09-11 | 2006-09-15 | 25, 24 |  |  | -26d | 0d |  | 2006-08-09 |  |
| 27 | 1.8.11 | Install receiver |  | 2d | 2006-09-18 | 2006-09-19 | 26, 21 |  |  | 2d |  |  |  |  |

| ID | WBS | Task | Type | Duration | Start | Finish | Predecessors | Total slack | Constraint | Text1 |
| --- | --- | --- | --- | --- | --- | --- | --- | --- | --- | --- |
| 29 | 1.9 | **Checkout** |  | 8d | 2006-09-22 | 2006-10-03 | 27, 23 | 0d |  |  |
| 30 | 1.9.1 | Check M/C and 1st point of Tx |  | 1d | 2006-09-22 | 2006-09-22 |  | 0d |  |  |
| 31 | 1.9.2 | Ensure Tx and Rx on correct frequency, confirm adequate received power |  | 1d | 2006-09-25 | 2006-09-25 | 30 | 0d |  |  |
| 32 | 1.9.3 | Peak transmitter pointing |  | 1d | 2006-09-26 | 2006-09-26 | 31 | 0d |  |  |
| 33 | 1.9.4 | Verify receiver complex output and stability |  | 1d | 2006-09-27 | 2006-09-27 | 32 | 0d |  |  |
| 34 | 1.9.5 | Margin |  | 4d | 2006-09-28 | 2006-10-03 | 33 | 0d |  |  |
| 36 | 1.10 | **e2e tests of the system** |  | 29d | 2006-10-04 | 2006-11-14 | 29 | 0d |  |  |
| 37 | 1.10.1 | Verfy mount movement and synch with data |  | 5d | 2006-10-04 | 2006-10-11 |  | 0d |  |  |
| 38 | 1.10.2 | Verify writing/reading from archive |  | 1d | 2006-10-12 | 2006-10-12 | 37 | 0d |  |  |
| 39 | 1.10.3 | Perform 1st raster and create database |  | 2d | 2006-10-13 | 2006-10-16 | 38 | 0d |  |  |
| 40 | 1.10.4 | Confirm data analysis and display are working correctly |  | 2d | 2006-10-17 | 2006-10-18 | 39 | 0d |  |  |
| 41 | 1.10.5 | Produce first holo image |  | 5d | 2006-10-19 | 2006-10-25 | 40 | 0d |  |  |
| 42 | 1.10.6 | measure, adjust focus and illumination |  | 2d | 2006-10-26 | 2006-10-27 | 41 | 0d |  |  |
| 43 | 1.10.7 | Margin |  | 12d | 2006-10-30 | 2006-11-14 | 42 | 0d |  |  |
| 45 | 1.11 | **Science Validation** |  | 18d | 2006-11-15 | 2006-12-12 | 36 | 0d |  |  |
| 46 | 1.11.1 | a few more images |  | 6d | 2006-11-15 | 2006-11-22 |  | 0d |  |  |
| 47 | 1.11.2 | Move antenna panel to calibrate |  | 2d | 2006-11-27 | 2006-11-28 | 46 | 0d |  |  |
| 48 | 1.11.3 | Integrated User Tests |  | 5d | 2006-11-29 | 2006-12-05 | 47 | 0d |  |  |
| 49 | 1.11.4 | Test Readiness Review |  | 1d | 2006-12-06 | 2006-12-06 | 48 | 0d |  |  |
| 50 | 1.11.5 | Software rework for high-priority problems |  | 5d | 2006-12-06 | 2006-12-12 | 49SS | 0d |  |  |
| 52 | 1.12 | Acceptance tests |  | 2d | 2006-12-13 | 2006-12-14 | 45 | 0d |  | Rick |
| 53 | 1.13 | Margin |  | 5d | 2006-12-15 | 2006-12-21 | 52 | 0d |  |  |
| 54 | 1.14 | Pack up |  | 5d | 2006-12-22 | 2006-12-28 | 53 | 0d |  | Dick |
| 55 | 1.15 | ship to Chile |  | 20d | 2006-12-29 | 2007-01-25 | 54 | 0d |  |  |
| 56 | 1.16 | Reconfigure sofware, install, test functionality in lab. |  | 10d | 2007-01-26 | 2007-02-08 | 55 | 0d | start no earlier than 2006-08-17 | Brian, Darre, Robert, AIV |
| 57 | 1.17 | Holography system ready for installation in first antenna. | milestone | 0d | 2007-02-08 | 2007-02-08 | 56 | 0d |  |  |
